# 00375r0P802-15_TG1-Project-Planning-Events

Schedule from MS Project, 1997-06-24 to 2001-12-06, scheduled back from the finish, A marks actual dates.
M/A-COM, Inc.

## Calendars

- Standard: Mon-Fri 08:00-12:00, 13:00-17:00; Sat-Sun off.

## Schedule

| ID | WBS | Task | Type | Duration | Start | Finish | Predecessors | Complete | Remaining | Total slack | Free slack | Constraint |
| --- | --- | --- | --- | --- | --- | --- | --- | --- | --- | --- | --- | --- |
| 1 | 1 | **802.15.1 Project Plan (Events)** |  | 1162d | 1997-06-24 A | 2001-12-06 |  | 26% | 858.41d | 725d | 0d | as late as possible |
| 2 | 1.1 | **IEEE Wearables Committee** |  | 152d | 1997-06-24 A | 1998-01-22 A |  | 100% |  |  |  | as late as possible |
| 3 | 1.1.1 | Start Fact Find |  | 1d | 1997-06-24 A | 1997-06-24 A |  | 100% |  |  |  | start no later than 1997-06-02 |
| 4 | 1.1.2 | Ad Hoc Meeting #1 |  | 1d | 1997-07-16 A | 1997-07-16 A | 3 | 100% |  |  |  | start no later than 1997-07-16 |
| 5 | 1.1.3 | Ad Hoc Meeting #2 |  | 1d | 1997-12-02 A | 1997-12-02 A | 4 | 100% |  |  |  | start no later than 1997-12-02 |
| 6 | 1.1.4 | Ad Hoc Meeting #3 |  | 2d | 1998-01-13 A | 1998-01-14 A | 5 | 100% |  |  |  | start no later than 1998-01-14 |
| 7 | 1.1.5 | Finish Fact Find | milestone | 0d | 1998-01-22 A | 1998-01-22 A | 6 | 100% |  |  |  | start no later than 1998-01-22 |
| 8 | 1.2 | **IEEE 802.11 WG for WLANs** |  | 300d | 1998-01-22 A | 1999-03-18 |  | 73% | 81.82d | 79d | 0d | as late as possible |
| 9 | 1.2.1 | Jan98 Interim Meeting |  | 1d | 1998-01-22 A | 1998-01-22 A | 7 | 100% |  |  |  | finish no later than 1998-01-22 |
| 10 | 1.2.2 | Mar98 Plenary Meeting |  | 5d | 1998-03-09 A | 1998-03-13 A | 9 | 100% |  |  |  | finish no later than 1998-03-12 |
| 11 | 1.2.3 | May98 Interim Meeting |  | 4d | 1998-05-04 A | 1998-05-07 A | 10 | 100% |  |  |  | finish no later than 1998-05-07 |
| 12 | 1.2.4 | Jul98 Plenary Meeting |  | 5d | 1998-07-06 A | 1998-07-10 A | 11 | 100% |  |  |  | finish no later than 1998-07-09 |
| 13 | 1.2.5 | Sep98 Interim Meeting |  | 4d | 1998-09-14 A | 1998-09-17 A | 12 | 100% |  |  |  | as late as possible |
| 14 | 1.2.6 | Nov98 Plenary Meeting |  | 5d | 1998-11-09 A | 1998-11-13 A | 13 | 100% |  |  |  | as late as possible |
| 15 | 1.2.7 | Jan99 Interim Meeting |  | 4d | 1999-01-11 | 1999-01-14 | 14 |  |  | 40d | 0d | start no later than 1999-01-11 |
| 16 | 1.2.8 | Mar99 Plenary Meeting |  | 5d | 1999-03-04 | 1999-03-10 | 15 |  |  | 74d | 0d | start no later than 1999-03-08 |
| 17 | 1.2.9 | SEC Approves PAR | milestone | 0d | 1999-03-11 | 1999-03-11 | 16 |  |  | 74d | 0d | start no later than 1999-03-11 |
| 18 | 1.2.10 | NesCom Meeting/PAR Approval | milestone | 0d | 1999-03-18 | 1999-03-18 | 17 |  |  | 79d | 0d | start no later than 1999-03-18 |
| 19 | 1.3 | **IEEE 802.15 WG for WPANs** |  | 676d | 1999-05-05 | 2001-12-06 |  |  |  | 502d | 0d | as late as possible |
| 20 | 1.3.1 | May99 Interim Meeting |  | 2d | 1999-05-05 | 1999-05-06 | 18 |  |  | 113d | 0d | start no later than 1999-05-05 |
| 21 | 1.3.2 | #1 Jul98 Plenary Meeting |  | 5d | 1999-07-05 | 1999-07-09 | 20 |  |  | 154d | 0d | start no later than 1999-07-05 |
| 22 | 1.3.3 | #2 Sep98 Interim Meeting |  | 5d | 1999-09-13 | 1999-09-17 | 21 |  |  | 199d | 0d | start no later than 1999-09-13 |
| 23 | 1.3.4 | #3 Nov98 Plenary Meeting |  | 5d | 1999-11-08 | 1999-11-12 | 22 |  |  | 234d | 0d | start no later than 1999-11-08 |
| 24 | 1.3.5 | #4 Jan00 Interim Meeting |  | 5d | 2000-01-10 | 2000-01-14 | 23 |  |  | 274d | 0d | start no later than 2000-01-10 |
| 25 | 1.3.6 | #5 Mar00 Plenary Meeting |  | 5d | 2000-03-06 | 2000-03-10 | 24 |  |  | 309d | 0d | start no later than 2000-03-06 |
| 26 | 1.3.7 | #6 May00 Interim Meeting |  | 5d | 2000-05-08 | 2000-05-12 | 25 |  |  | 349d | 0d | start no later than 2000-05-08 |
| 27 | 1.3.8 | #7 Jul00 Plenary Meeting |  | 5d | 2000-07-10 | 2000-07-14 | 26 |  |  | 389d | 0d | start no later than 2000-07-10 |
| 28 | 1.3.9 | #8 Sep00 Interim Meeting |  | 5d | 2000-09-18 | 2000-09-22 | 27 |  |  | 434d | 0d | start no later than 2000-09-18 |
| 29 | 1.3.10 | #9 Nov00 Plenary Meeting |  | 4d | 2000-11-06 | 2000-11-09 | 28 |  |  | 464d | 0d | start no later than 2000-11-06 |
| 30 | 1.3.11 | #10 Jan01 Interim Meeting |  | 5d | 2001-01-15 | 2001-01-19 | 29 |  |  | 510d | 0d | start no later than 2001-01-15 |
| 31 | 1.3.12 | #11 Mar01 Plenary Meeting |  | 4d | 2001-03-12 | 2001-03-15 | 30 |  |  | 545d | 0d | start no later than 2001-03-12 |
| 32 | 1.3.13 | Draft & PAR Submission Deadline | milestone | 0d | 2001-05-04 | 2001-05-04 | 31 |  |  | 580d | 0d | start no later than 2001-05-04 |
| 33 | 1.3.14 | #12 May01 Interim Meeting |  | 5d | 2001-05-07 | 2001-05-11 | 32 |  |  | 581d | 0d | start no later than 2001-05-07 |
| 34 | 1.3.15 | #13 Jul01 Plenary Meeting |  | 4d | 2001-07-09 | 2001-07-12 | 33 |  |  | 621d | 0d | start no later than 2001-07-09 |
| 35 | 1.3.16 | Draft & PAR Submission Deadline | milestone | 0d | 2001-08-03 | 2001-08-03 | 34 |  |  | 636d | 0d | start no later than 2001-08-03 |
| 36 | 1.3.17 | RevCom Meeting | milestone | 0d | 2001-09-13 | 2001-09-13 | 35 |  |  | 665d | 0d | start no later than 2001-09-13 |
| 38 | 1.3.18 | #14 Sep01 Interim Meeting |  | 5d | 2001-09-17 | 2001-09-21 |  |  |  | 1120d | 0d | start no later than 2001-09-17 |
| 39 | 1.3.19 | #15 Nov01 Plenary Meeting |  | 4d | 2001-11-12 | 2001-11-15 |  |  |  | 1160d | 0d | start no later than 2001-11-12 |
| 40 | 1.3.20 | Draft & PAR Submission Deadline | milestone | 0d | 2001-10-26 | 2001-10-26 |  |  |  | 1149d | 0d | start no later than 2001-10-26 |
| 41 | 1.3.21 | RevCom Meeting | milestone | 0d | 2001-12-06 | 2001-12-06 |  |  |  | 1178d | 0d | start no later than 2001-12-06 |

Notes:
- 2: Blah
